# 150kV-275kV UleeKareng

Schedule from MS Project, 2025-08-04 to 2026-08-21.

## Calendars

- Standard: Mon-Fri 08:00-12:00, 13:00-17:00; Sat-Sun off.

## Schedule

| ID | WBS | Task | Type | Duration | Start | Finish | Predecessors | Total slack | Free slack | Constraint |
| --- | --- | --- | --- | --- | --- | --- | --- | --- | --- | --- |
| 1 | 1 | **PEKERJAAN PEMBANGUNAN GI 150kV & 275kV ULEE KARENG** |  | 275d | 2025-08-04 | 2026-08-21 |  | 0d |  |  |
| 2 | 1.1 | START PROYEK | milestone | 0d | 2025-08-04 | 2025-08-04 |  | 0d |  |  |
| 3 | 1.2 | FINISH PROYEK | milestone | 0d | 2026-08-21 | 2026-08-21 | 107FS+7d | 0d |  |  |
| 4 | 2 | **PEKERJAAN SIPIL Pembangunan GI 150 kV Ulee Kareng (1 x 60 MVA)** |  | 250d | 2025-08-04 | 2026-07-17 |  | 0d |  |  |
| 5 | 2.1 | **PEKERJAAN PENYELIDIKAN DAN PEMATANGAN TANAH** |  | 14d | 2025-08-04 | 2025-08-21 |  | 0d |  |  |
| 6 | 2.1.1 | PO |  | 2d | 2025-08-04 | 2025-08-05 | 2 | 0d |  |  |
| 7 | 2.1.2 | Pelaksanaan |  | 12d | 2025-08-06 | 2025-08-21 | 6 | 0d |  |  |
| 8 | 2.2 | **PEKERJAAN PRASARANA, SWITCHYARD, & PONDASI** |  | 236d | 2025-08-22 | 2026-07-17 |  | 0d |  |  |
| 9 | 2.2.1 | **150 kV GITET ULEE KARENG** |  | 236d | 2025-08-22 | 2026-07-17 |  | 0d |  |  |
| 10 | 2.2.1.1 | PERALATAN ELEKTROMEKANIK 150kV LINE BAY |  | 21d | 2025-08-22 | 2025-09-19 | 7 | 0d |  |  |
| 11 | 2.2.1.2 | PENGADAAN PERALATAN ELEKTROMEKANIK 150kV TRANSFORMER BAY |  | 21d | 2025-09-26 | 2025-10-24 | 7, 10FS+4d | 0d |  |  |
| 12 | 2.2.1.3 | PERALATAN ELEKTROMEKANIK 150kV BUS COUPLER BAY |  | 21d | 2025-10-31 | 2025-11-28 | 7, 11FS+4d | 0d |  |  |
| 13 | 2.2.1.4 | PERALATAN ELEKTROMEKANIK |  | 21d | 2025-12-05 | 2026-01-02 | 7, 12FS+4d | 0d |  |  |
| 14 | 2.2.1.5 | 150kV INCOMING INTERBUS TRANSFORMER BAY |  | 21d | 2026-01-09 | 2026-02-06 | 7, 13FS+4d | 0d |  |  |
| 15 | 2.2.1.6 | PERALATAN ELEKTROMEKANIK 150kV BUS BAR BAY |  | 21d | 2026-02-13 | 2026-03-13 | 7, 14FS+4d | 0d |  |  |
| 16 | 2.2.1.7 | 20 kV SWITCHGEAR, POWER CABLE AND AUXILIARY SERVICE TRANSFORMER AND REMOTE CONTROL PANEL FROM 150 KV TRANSFORMER |  | 25d | 2026-05-26 | 2026-06-29 | 7, 10FS+4d, 11FS+4d, 12FS+4d, 13FS+4d, 14FS+4d, 15FS+4d, 18FS+1d | 25d | 0d |  |
| 17 | 2.2.1.8 | 20 kV SWITCHGEAR, POWER CABLE AND AUXILIARY SERVICE TRANSFORMER FROM IBT |  | 25d | 2026-03-20 | 2026-04-23 | 7, 10FS+4d, 11FS+4d, 12FS+4d, 13FS+4d, 14FS+4d, 15FS+4d | 72d | 47d |  |
| 18 | 2.2.1.9 | 150 KV SWITCHYARD STEEL STRUCTURES |  | 36d | 2026-04-03 | 2026-05-22 | 7, 10FS+14d, 11FS+14d, 12FS+14d, 13FS+14d, 14FS+14d, 15FS+14d, 149 | 0d |  |  |
| 19 | 2.2.1.10 | SUBSTATION AUXILLIARIES EQUIPMENT |  | 14d | 2026-05-26 | 2026-06-12 | 16SS, 17SS | 50d |  |  |
| 20 | 2.2.1.11 | PROTECTION & SUBSTATION AUTOMATION SYSTEM (SAS) |  | 14d | 2026-06-30 | 2026-07-17 | 16, 17 | 25d |  |  |
| 21 | 2.2.2 | **275 kV GITET ULEE KARENG** |  | 14d | 2026-03-17 | 2026-04-03 |  | 72d |  |  |
| 22 | 2.2.2.1 | 275 kV OUTDOOR EQUIPMENT FOR OVER HEAD LINE FEEDER BAY |  | 14d | 2026-03-17 | 2026-04-03 | 10FS+1d, 11FS+1d, 12FS+1d, 13FS+1d, 14FS+1d, 15FS+1d | 72d | 0d |  |
| 23 | 2.3 | **PEKERJAAN PENGUJIAN BETON** |  | 42d | 2026-03-17 | 2026-05-13 |  | 72d |  |  |
| 24 | 2.3.1 | 150 kV GITET ULEE KARENG |  | 28d | 2026-03-17 | 2026-04-23 | 15FF+28d | 86d |  | finish no earlier than 2026-04-23 |
| 25 | 2.3.2 | 275 kV GITET ULEE KARENG |  | 28d | 2026-04-06 | 2026-05-13 | 22 | 72d |  |  |

| ID | WBS | Task | Duration | Start | Finish | Predecessors | Total slack | Free slack |
| --- | --- | --- | --- | --- | --- | --- | --- | --- |
| 26 | 3 | **PEKERJAAN ELEKTROMEKANIK Pembangunan GI 150 kV Ulee Kareng (1 x 60 MVA)** | 72d | 2025-08-04 | 2025-11-11 |  | 102d |  |
| 27 | 3.1 | **150 kV GITET ULEE KARENG** | 72d | 2025-08-04 | 2025-11-11 |  | 102d |  |
| 28 | 3.1.1 | **PENGADAAN PERALATAN ELEKTROMEKANIK 150kV LINE BAY** | 33d | 2025-08-04 | 2025-09-17 |  | 102d |  |
| 29 | 3.1.1.1 | PO material | 3d | 2025-08-04 | 2025-08-06 | 2 | 102d | 0d |
| 30 | 3.1.1.2 | Detailed Engineering | 14d | 2025-08-07 | 2025-08-26 | 29 | 185d | 0d |
| 31 | 3.1.1.3 | Fabrication | 14d | 2025-08-27 | 2025-09-15 | 30 | 185d | 0d |
| 32 | 3.1.1.4 | FAT | 2d | 2025-09-16 | 2025-09-17 | 31 | 185d | 0d |
| 33 | 3.1.2 | **PENGADAAN PERALATAN ELEKTROMEKANIK 150kV TRANSFORMER BAY** | 33d | 2025-08-07 | 2025-09-22 |  | 102d |  |
| 34 | 3.1.2.1 | PO material | 3d | 2025-08-07 | 2025-08-11 | 29 | 102d | 0d |
| 35 | 3.1.2.2 | Detailed Engineering | 14d | 2025-08-12 | 2025-08-29 | 34 | 182d | 0d |
| 36 | 3.1.2.3 | Fabrication | 14d | 2025-09-01 | 2025-09-18 | 35 | 182d | 0d |
| 37 | 3.1.2.4 | FAT | 2d | 2025-09-19 | 2025-09-22 | 36 | 182d | 0d |
| 38 | 3.1.3 | **PENGADAAN PERALATAN ELEKTROMEKANIK 150kV BUS COUPLER BAY** | 33d | 2025-08-12 | 2025-09-25 |  | 102d |  |
| 39 | 3.1.3.1 | PO material | 3d | 2025-08-12 | 2025-08-14 | 34 | 102d | 0d |
| 40 | 3.1.3.2 | Detailed Engineering | 14d | 2025-08-15 | 2025-09-03 | 39 | 179d | 0d |
| 41 | 3.1.3.3 | Fabrication | 14d | 2025-09-04 | 2025-09-23 | 40 | 179d | 0d |
| 42 | 3.1.3.4 | FAT | 2d | 2025-09-24 | 2025-09-25 | 41 | 179d | 0d |
| 43 | 3.1.4 | **PENGADAAN PERALATAN ELEKTROMEKANIK** | 31d | 2025-08-15 | 2025-09-26 |  | 102d |  |
| 44 | 3.1.4.1 | PO material | 3d | 2025-08-15 | 2025-08-19 | 39 | 102d | 0d |
| 45 | 3.1.4.2 | Detailed Engineering | 14d | 2025-08-20 | 2025-09-08 | 44 | 176d | 0d |
| 46 | 3.1.4.3 | Fabrication | 14d | 2025-09-09 | 2025-09-26 | 45 | 176d | 0d |
| 47 | 3.1.5 | FAT | 2d | 2025-09-29 | 2025-09-30 | 46 | 176d | 0d |
| 48 | 3.1.6 | **150kV INCOMING INTERBUS TRANSFORMER BAY** | 33d | 2025-08-20 | 2025-10-03 |  | 102d |  |
| 49 | 3.1.6.1 | PO material | 3d | 2025-08-20 | 2025-08-22 | 44 | 102d | 0d |
| 50 | 3.1.6.2 | Detailed Engineering | 14d | 2025-08-25 | 2025-09-11 | 49 | 173d | 0d |
| 51 | 3.1.6.3 | Fabrication | 14d | 2025-09-12 | 2025-10-01 | 50 | 173d | 0d |
| 52 | 3.1.6.4 | FAT | 2d | 2025-10-02 | 2025-10-03 | 51 | 173d | 0d |

| ID | WBS | Task | Duration | Start | Finish | Predecessors | Total slack | Free slack | Constraint |
| --- | --- | --- | --- | --- | --- | --- | --- | --- | --- |
| 53 | 3.1.7 | **PENGADAAN PERALATAN ELEKTROMEKANIK 150kV BUS BAR BAY** | 33d | 2025-08-25 | 2025-10-08 |  | 102d |  |  |
| 54 | 3.1.7.1 | PO material | 3d | 2025-08-25 | 2025-08-27 | 49 | 102d | 0d | finish no earlier than 2025-08-22 |
| 55 | 3.1.7.2 | Detailed Engineering | 14d | 2025-08-28 | 2025-09-16 | 54 | 170d | 0d | finish no earlier than 2025-09-11 |
| 56 | 3.1.7.3 | Fabrication | 14d | 2025-09-17 | 2025-10-06 | 55 | 170d | 0d | finish no earlier than 2025-10-01 |
| 57 | 3.1.7.4 | FAT | 2d | 2025-10-07 | 2025-10-08 | 56 | 170d | 0d | finish no earlier than 2025-10-03 |
| 58 | 3.1.8 | **20 kV SWITCHGEAR, POWER CABLE AND AUXILIARY SERVICE TRANSFORMER AND REMOTE CONTROL PANEL FROM 150 KV TRANSFORMER** | 33d | 2025-08-28 | 2025-10-13 |  | 102d |  |  |
| 59 | 3.1.8.1 | PO material | 3d | 2025-08-28 | 2025-09-01 | 54 | 102d | 0d |  |
| 60 | 3.1.8.2 | Detailed Engineering | 14d | 2025-09-02 | 2025-09-19 | 59 | 167d | 0d |  |
| 61 | 3.1.8.3 | Fabrication | 14d | 2025-09-22 | 2025-10-09 | 60 | 167d | 0d |  |
| 62 | 3.1.8.4 | FAT | 2d | 2025-10-10 | 2025-10-13 | 61 | 167d | 0d |  |
| 63 | 3.1.9 | **20 kV SWITCHGEAR, POWER CABLE AND AUXILIARY SERVICE TRANSFORMER FROM IBT** | 33d | 2025-09-02 | 2025-10-16 |  | 102d |  |  |
| 64 | 3.1.9.1 | PO material | 3d | 2025-09-02 | 2025-09-04 | 59 | 102d | 0d |  |
| 65 | 3.1.9.2 | Detailed Engineering | 14d | 2025-09-05 | 2025-09-24 | 64 | 164d | 0d |  |
| 66 | 3.1.9.3 | Fabrication | 14d | 2025-09-25 | 2025-10-14 | 65 | 164d | 0d |  |
| 67 | 3.1.9.4 | FAT | 2d | 2025-10-15 | 2025-10-16 | 66 | 164d | 0d |  |
| 68 | 3.1.10 | **150 KV SWITCHYARD STEEL STRUCTURES** | 33d | 2025-09-05 | 2025-10-21 |  | 102d |  |  |
| 69 | 3.1.10.1 | PO material | 3d | 2025-09-05 | 2025-09-09 | 64 | 102d | 0d |  |
| 70 | 3.1.10.2 | Detailed Engineering | 14d | 2025-09-10 | 2025-09-29 | 69 | 102d | 0d |  |
| 71 | 3.1.10.3 | Fabrication | 14d | 2025-09-30 | 2025-10-17 | 70 | 102d | 0d |  |
| 72 | 3.1.10.4 | FAT | 2d | 2025-10-20 | 2025-10-21 | 71 | 102d | 0d |  |
| 73 | 3.1.11 | **SHIELD WIRE AND ACCESSORIES** | 33d | 2025-09-10 | 2025-10-24 |  | 129d |  |  |
| 74 | 3.1.11.1 | PO material | 3d | 2025-09-10 | 2025-09-12 | 69 | 129d | 0d |  |
| 75 | 3.1.11.2 | Detailed Engineering | 14d | 2025-09-15 | 2025-10-02 | 74 | 151d | 0d |  |
| 76 | 3.1.11.3 | Fabrication | 14d | 2025-10-03 | 2025-10-22 | 75 | 151d | 0d |  |
| 77 | 3.1.11.4 | FAT | 2d | 2025-10-23 | 2025-10-24 | 76 | 151d | 0d |  |

| ID | WBS | Task | Duration | Start | Finish | Predecessors | Total slack | Free slack |
| --- | --- | --- | --- | --- | --- | --- | --- | --- |
| 78 | 3.1.12 | **SUBSTATION EARTING SYSTEM** | 33d | 2025-09-15 | 2025-10-29 |  | 129d |  |
| 79 | 3.1.12.1 | PO material | 3d | 2025-09-15 | 2025-09-17 | 74 | 129d | 0d |
| 80 | 3.1.12.2 | Detailed Engineering | 14d | 2025-09-18 | 2025-10-07 | 79 | 148d | 0d |
| 81 | 3.1.12.3 | Fabrication | 14d | 2025-10-08 | 2025-10-27 | 80 | 148d | 0d |
| 82 | 3.1.12.4 | FAT | 2d | 2025-10-28 | 2025-10-29 | 81 | 148d | 0d |
| 83 | 3.1.13 | **LV power cable, control cable and accessories and necessary equipment** | 33d | 2025-09-18 | 2025-11-03 |  | 129d |  |
| 84 | 3.1.13.1 | PO material | 3d | 2025-09-18 | 2025-09-22 | 79 | 129d | 0d |
| 85 | 3.1.13.2 | Detailed Engineering | 14d | 2025-09-23 | 2025-10-10 | 84 | 129d | 0d |
| 86 | 3.1.13.3 | Fabrication | 14d | 2025-10-13 | 2025-10-30 | 85 | 129d | 0d |
| 87 | 3.1.13.4 | FAT | 2d | 2025-10-31 | 2025-11-03 | 86 | 129d | 0d |
| 88 | 3.1.14 | **SUBSTATION AUXILLIARIES EQUIPMENT** | 33d | 2025-09-23 | 2025-11-06 |  | 139d |  |
| 89 | 3.1.14.1 | PO material | 3d | 2025-09-23 | 2025-09-25 | 84 | 139d | 0d |
| 90 | 3.1.14.2 | Detailed Engineering | 14d | 2025-09-26 | 2025-10-15 | 89 | 149d | 0d |
| 91 | 3.1.14.3 | Fabrication | 14d | 2025-10-16 | 2025-11-04 | 90 | 149d | 0d |
| 92 | 3.1.14.4 | FAT | 2d | 2025-11-05 | 2025-11-06 | 91 | 149d | 0d |
| 93 | 3.1.15 | **PROTECTION & SUBSTATION AUTOMATION SYSTEM (SAS)** | 33d | 2025-09-26 | 2025-11-11 |  | 139d |  |
| 94 | 3.1.15.1 | PO material | 3d | 2025-09-26 | 2025-09-30 | 89, 100 | 139d | 0d |
| 95 | 3.1.15.2 | Detailed Engineering | 14d | 2025-10-01 | 2025-10-20 | 94 | 139d | 0d |
| 96 | 3.1.15.3 | Fabrication | 14d | 2025-10-21 | 2025-11-07 | 95 | 139d | 0d |
| 97 | 3.1.15.4 | FAT | 2d | 2025-11-10 | 2025-11-11 | 96 | 139d | 0d |
| 98 | 3.2 | **275 kV GITET ULEE KARENG** | 33d | 2025-08-28 | 2025-10-13 |  | 157d | 27d |
| 99 | 3.2.1 | **275 kV OUTDOOR EQUIPMENT FOR OVER HEAD LINE FEEDER BAY** | 33d | 2025-08-28 | 2025-10-13 |  | 157d | 0d |
| 100 | 3.2.1.1 | PO material | 3d | 2025-08-28 | 2025-09-01 | 54 | 157d | 0d |
| 101 | 3.2.1.2 | Detailed Engineering | 14d | 2025-09-02 | 2025-09-19 | 100 | 162d | 0d |
| 102 | 3.2.1.3 | Fabrication | 14d | 2025-09-22 | 2025-10-09 | 101 | 162d | 0d |
| 103 | 3.2.1.4 | FAT | 2d | 2025-10-10 | 2025-10-13 | 102 | 196d |  |

| ID | WBS | Task | Duration | Start | Finish | Predecessors | Total slack | Free slack |
| --- | --- | --- | --- | --- | --- | --- | --- | --- |
| 104 | 4 | **TESTING & COMMISSIONING 150 kV** | 181d | 2025-12-03 | 2026-08-12 |  | 0d |  |
| 105 | 4.1 | PO Team Test Com | 3d | 2025-12-03 | 2025-12-05 | 113 | 150d |  |
| 106 | 4.2 | Pelaksanaan Individual Test | 14d | 2026-07-06 | 2026-07-23 | 105, 175, 27 | 0d |  |
| 107 | 4.3 | Commissioning | 14d | 2026-07-24 | 2026-08-12 | 106 | 0d |  |
| 108 | 5 | **TESTING & COMMISSIONING 275 kV** | 106d | 2025-08-04 | 2025-12-29 |  |  |  |
| 109 | 5.1 | PO Team Test Com | 3d | 2025-10-31 | 2025-11-04 | 174 | 208d |  |
| 110 | 5.2 | Pelaksanaan Individual Test | 14d | 2025-11-20 | 2025-12-09 | 191, 98 | 169d | 0d |
| 111 | 5.3 | Commissioning | 14d | 2025-12-10 | 2025-12-29 | 110 | 169d |  |
| 112 | 6 | **TRANSPORTASI MATERIAL EM** | 84d | 2025-08-07 | 2025-12-02 |  | 156d |  |
| 113 | 6.1 | **150 kV GITET ULEE KARENG** | 84d | 2025-08-07 | 2025-12-02 |  | 150d | 0d |
| 114 | 6.1.1 | **PERALATAN ELEKTROMEKANIK 150kV LINE BAY** | 45d | 2025-08-07 | 2025-10-08 |  | 189d |  |
| 115 | 6.1.1.1 | PO Transport | 3d | 2025-08-07 | 2025-08-11 | 29 | 231d |  |
| 116 | 6.1.1.2 | Pengiriman | 14d | 2025-09-18 | 2025-10-07 | 32 | 185d | 0d |
| 117 | 6.1.1.3 | On Site | 1d | 2025-10-08 | 2025-10-08 | 116 | 185d | 162d |
| 118 | 6.1.2 | **PENGADAAN PERALATAN ELEKTROMEKANIK 150kV TRANSFORMER BAY** | 45d | 2025-08-12 | 2025-10-13 |  | 186d |  |
| 119 | 6.1.2.1 | PO Transport | 3d | 2025-08-12 | 2025-08-14 | 34 | 228d |  |
| 120 | 6.1.2.2 | Pengiriman | 14d | 2025-09-23 | 2025-10-10 | 37 | 182d | 0d |
| 121 | 6.1.2.3 | On Site | 1d | 2025-10-13 | 2025-10-13 | 120 | 182d | 159d |
| 122 | 6.1.3 | **PERALATAN ELEKTROMEKANIK 150kV BUS COUPLER BAY** | 45d | 2025-08-15 | 2025-10-16 |  | 183d |  |
| 123 | 6.1.3.1 | PO Transport | 3d | 2025-08-15 | 2025-08-19 | 39 | 225d |  |
| 124 | 6.1.3.2 | Pengiriman | 14d | 2025-09-26 | 2025-10-15 | 42 | 179d | 0d |
| 125 | 6.1.3.3 | On Site | 1d | 2025-10-16 | 2025-10-16 | 124 | 179d | 156d |
| 126 | 6.1.4 | **PERALATAN ELEKTROMEKANIK** | 45d | 2025-08-20 | 2025-10-21 |  | 180d |  |
| 127 | 6.1.4.1 | PO Transport | 3d | 2025-08-20 | 2025-08-22 | 44 | 222d |  |
| 128 | 6.1.4.2 | Pengiriman | 14d | 2025-10-01 | 2025-10-20 | 47 | 176d | 0d |
| 129 | 6.1.4.3 | On Site | 1d | 2025-10-21 | 2025-10-21 | 128 | 176d | 153d |

| ID | WBS | Task | Duration | Start | Finish | Predecessors | Total slack | Free slack |
| --- | --- | --- | --- | --- | --- | --- | --- | --- |
| 130 | 6.1.5 | **150kV INCOMING INTERBUS TRANSFORMER BAY** | 45d | 2025-08-25 | 2025-10-24 |  | 177d |  |
| 131 | 6.1.5.1 | PO Transport | 3d | 2025-08-25 | 2025-08-27 | 49 | 219d |  |
| 132 | 6.1.5.2 | Pengiriman | 14d | 2025-10-06 | 2025-10-23 | 52 | 173d | 0d |
| 133 | 6.1.5.3 | On Site | 1d | 2025-10-24 | 2025-10-24 | 132 | 173d | 150d |
| 134 | 6.1.6 | **PERALATAN ELEKTROMEKANIK 150kV BUS BAR BAY** | 45d | 2025-08-28 | 2025-10-29 |  | 174d |  |
| 135 | 6.1.6.1 | PO Transport | 3d | 2025-08-28 | 2025-09-01 | 54 | 216d |  |
| 136 | 6.1.6.2 | Pengiriman | 14d | 2025-10-09 | 2025-10-28 | 57 | 170d | 0d |
| 137 | 6.1.6.3 | On Site | 1d | 2025-10-29 | 2025-10-29 | 136 | 170d | 147d |
| 138 | 6.1.7 | **20 kV SWITCHGEAR, POWER CABLE AND AUXILIARY SERVICE TRANSFORMER AND REMOTE CONTROL PANEL FROM 150 KV TRANSFORMER** | 45d | 2025-09-02 | 2025-11-03 |  | 171d |  |
| 139 | 6.1.7.1 | PO Transport | 3d | 2025-09-02 | 2025-09-04 | 59 | 213d |  |
| 140 | 6.1.7.2 | Pengiriman | 14d | 2025-10-14 | 2025-10-31 | 62 | 167d | 0d |
| 141 | 6.1.7.3 | On Site | 1d | 2025-11-03 | 2025-11-03 | 140 | 167d | 144d |
| 142 | 6.1.8 | **20 kV SWITCHGEAR, POWER CABLE AND AUXILIARY SERVICE TRANSFORMER FROM IBT** | 45d | 2025-09-05 | 2025-11-06 |  | 168d |  |
| 143 | 6.1.8.1 | PO Transport | 3d | 2025-09-05 | 2025-09-09 | 64 | 210d |  |
| 144 | 6.1.8.2 | Pengiriman | 14d | 2025-10-17 | 2025-11-05 | 67 | 164d | 0d |
| 145 | 6.1.8.3 | On Site | 1d | 2025-11-06 | 2025-11-06 | 144 | 164d | 141d |
| 146 | 6.1.9 | **150 KV SWITCHYARD STEEL STRUCTURES** | 58d | 2025-08-22 | 2025-11-11 |  | 145d |  |
| 147 | 6.1.9.1 | PO Transport | 3d | 2025-08-22 | 2025-08-26 | 5 | 220d |  |
| 148 | 6.1.9.2 | Pengiriman | 14d | 2025-10-22 | 2025-11-10 | 72 | 102d | 0d |
| 149 | 6.1.9.3 | On Site | 1d | 2025-11-11 | 2025-11-11 | 148 | 102d |  |
| 150 | 6.1.10 | **SHIELD WIRE AND ACCESSORIES** | 45d | 2025-09-15 | 2025-11-14 |  | 162d |  |
| 151 | 6.1.10.1 | PO Transport | 3d | 2025-09-15 | 2025-09-17 | 74 | 204d |  |
| 152 | 6.1.10.2 | Pengiriman | 14d | 2025-10-27 | 2025-11-13 | 77 | 151d | 0d |
| 153 | 6.1.10.3 | On Site | 1d | 2025-11-14 | 2025-11-14 | 152 | 151d | 135d |

| ID | WBS | Task | Duration | Start | Finish | Predecessors | Total slack | Free slack |
| --- | --- | --- | --- | --- | --- | --- | --- | --- |
| 154 | 6.1.11 | **SUBSTATION EARTING SYSTEM** | 45d | 2025-09-18 | 2025-11-19 |  | 159d |  |
| 155 | 6.1.11.1 | PO Transport | 3d | 2025-09-18 | 2025-09-22 | 79 | 201d |  |
| 156 | 6.1.11.2 | Pengiriman | 14d | 2025-10-30 | 2025-11-18 | 82 | 148d | 0d |
| 157 | 6.1.11.3 | On Site | 1d | 2025-11-19 | 2025-11-19 | 156 | 148d | 132d |
| 158 | 6.1.12 | **LV power cable, control cable and accessories and necessary equipment** | 45d | 2025-09-23 | 2025-11-24 |  | 156d |  |
| 159 | 6.1.12.1 | PO Transport | 3d | 2025-09-23 | 2025-09-25 | 84 | 198d |  |
| 160 | 6.1.12.2 | Pengiriman | 14d | 2025-11-04 | 2025-11-21 | 87 | 129d | 0d |
| 161 | 6.1.12.3 | On Site | 1d | 2025-11-24 | 2025-11-24 | 160 | 129d |  |
| 162 | 6.1.13 | **SUBSTATION AUXILLIARIES EQUIPMENT** | 45d | 2025-09-26 | 2025-11-27 |  | 153d |  |
| 163 | 6.1.13.1 | PO Transport | 3d | 2025-09-26 | 2025-09-30 | 89 | 195d |  |
| 164 | 6.1.13.2 | Pengiriman | 14d | 2025-11-07 | 2025-11-26 | 92 | 149d | 0d |
| 165 | 6.1.13.3 | On Site | 1d | 2025-11-27 | 2025-11-27 | 164 | 149d | 126d |
| 166 | 6.1.14 | **PROTECTION & SUBSTATION AUTOMATION SYSTEM (SAS)** | 45d | 2025-10-01 | 2025-12-02 |  | 150d |  |
| 167 | 6.1.14.1 | PO Transport | 3d | 2025-10-01 | 2025-10-03 | 94 | 192d |  |
| 168 | 6.1.14.2 | Pengiriman | 14d | 2025-11-12 | 2025-12-01 | 97 | 139d | 0d |
| 169 | 6.1.14.3 | On Site | 1d | 2025-12-02 | 2025-12-02 | 168 | 139d | 123d |
| 170 | 6.2 | **275 kV GITET ULEE KARENG** | 15d | 2025-10-10 | 2025-10-30 |  | 162d |  |
| 171 | 6.2.1 | **275 kV OUTDOOR EQUIPMENT FOR OVER HEAD LINE FEEDER BAY** | 15d | 2025-10-10 | 2025-10-30 |  | 162d |  |
| 172 | 6.2.1.1 | PO Transport | 3d | 2025-10-14 | 2025-10-16 | 99 | 221d |  |
| 173 | 6.2.1.2 | Pengiriman | 14d | 2025-10-10 | 2025-10-29 | 102 | 162d | 0d |
| 174 | 6.2.1.3 | On Site | 1d | 2025-10-30 | 2025-10-30 | 173 | 162d | 0d |
| 175 | 7 | **PEMASANGAN MATERIAL EM** | 176d | 2025-10-31 | 2026-07-03 |  | 0d |  |
| 176 | 7.1 | **150 kV GITET ULEE KARENG** | 30d | 2026-05-25 | 2026-07-03 |  | 0d |  |
| 177 | 7.1.1 | PERALATAN ELEKTROMEKANIK 150kV LINE BAY | 7d | 2026-05-25 | 2026-06-02 | 18, 117 | 23d |  |
| 178 | 7.1.2 | PERALATAN ELEKTROMEKANIK 150kV TRANSFORMER BAY | 7d | 2026-05-25 | 2026-06-02 | 18, 121 | 23d |  |
| 179 | 7.1.3 | PERALATAN ELEKTROMEKANIK 150kV BUS COUPLER BAY | 7d | 2026-05-25 | 2026-06-02 | 18, 125 | 23d |  |
| 180 | 7.1.4 | PERALATAN ELEKTROMEKANIK | 7d | 2026-05-25 | 2026-06-02 | 18, 129 | 23d |  |
| 181 | 7.1.5 | 150kV INCOMING INTERBUS TRANSFORMER BAY | 7d | 2026-05-25 | 2026-06-02 | 18, 133 | 23d |  |
| 182 | 7.1.6 | PERALATAN ELEKTROMEKANIK 150kV BUS BAR BAY | 7d | 2026-05-25 | 2026-06-02 | 18, 137 | 23d |  |
| 183 | 7.1.7 | 20 kV SWITCHGEAR, POWER CABLE AND AUXILIARY SERVICE TRANSFORMER AND REMOTE CONTROL PANEL FROM 150 KV TRANSFORMER | 7d | 2026-05-25 | 2026-06-02 | 18, 141 | 23d |  |
| 184 | 7.1.8 | 20 kV SWITCHGEAR, POWER CABLE AND AUXILIARY SERVICE TRANSFORMER FROM IBT | 7d | 2026-05-25 | 2026-06-02 | 18, 145 | 23d |  |
| 185 | 7.1.9 | SHIELD WIRE AND ACCESSORIES | 14d | 2026-05-25 | 2026-06-11 | 18, 153 | 16d |  |
| 186 | 7.1.10 | SUBSTATION EARTING SYSTEM | 14d | 2026-05-25 | 2026-06-11 | 18, 157 | 16d |  |
| 187 | 7.1.11 | LV power cable, control cable and accessories and necessary equipment | 30d | 2026-05-25 | 2026-07-03 | 18, 161 | 0d |  |
| 188 | 7.1.12 | SUBSTATION AUXILLIARIES EQUIPMENT | 7d | 2026-05-25 | 2026-06-02 | 18, 165 | 23d |  |
| 189 | 7.1.13 | PROTECTION & SUBSTATION AUTOMATION SYSTEM (SAS) | 14d | 2026-05-25 | 2026-06-11 | 18, 169 | 16d |  |

| ID | WBS | Task | Duration | Start | Finish | Predecessors | Total slack | Free slack |
| --- | --- | --- | --- | --- | --- | --- | --- | --- |
| 190 | 7.2 | **275 kV GITET ULEE KARENG** | 14d | 2025-10-31 | 2025-11-19 |  | 162d |  |
| 191 | 7.2.1 | 275 kV OUTDOOR EQUIPMENT FOR OVER HEAD LINE FEEDER BAY | 14d | 2025-10-31 | 2025-11-19 | 174 | 162d | 0d |
| 192 | 8 | SHOP DRAWING | 120d | 2025-12-30 | 2026-06-15 | 175FF-14d | 49d |  |
| 193 | 9 | AS BUILT DRAWING | 30d | 2026-05-21 | 2026-07-01 | 104FF-30d | 37d |  |
| 194 | 10 | PERALATAN K3 | 240d | 2025-08-04 | 2026-07-03 | 2 | 35d |  |
